# GanttFinal

Schedule from MS Project, 2014-06-02 to 2015-03-26.

## Calendars

- Estándar: Mon-Fri 09:00-13:00, 15:00-19:00; Sat-Sun off.

## Schedule

| ID | Task | Type | Duration | Start | Finish | Predecessors | Total slack | Free slack | Constraint |
| --- | --- | --- | --- | --- | --- | --- | --- | --- | --- |
| 1 | WORK BEGINING |  | 1d | 2014-06-02 | 2014-06-02 |  | 213d |  | start no earlier than 2014-06-02 |
| 2 | Variation Order |  | 1d | 2014-06-02 | 2014-06-02 |  | 1d | 0d | start no earlier than 2014-06-02 |
| 3 | PREVIOS WORK | manual | 30d | 2014-06-03 | 2014-07-14 |  |  |  |  |
| 4 | Permits and Licenses |  | 10d | 2014-06-03 | 2014-06-16 | 2 | 1d | 0d |  |
| 5 | Fenced Plot |  | 10d | 2014-06-17 | 2014-06-30 | 4 | 1d | 0d |  |
| 6 | Provisional Rush, Site Facilities |  | 10d | 2014-07-01 | 2014-07-14 | 5 | 1d | 0d |  |
| 7 | EARTHWORKS AND SANITATION |  | 16d | 2014-06-03 | 2014-06-24 |  | 197d |  |  |
| 8 | Land clearing and Cleaning |  | 8d | 2014-07-15 | 2014-07-24 | 6 | 1d | 0d |  |
| 9 | Excavation |  | 2d | 2014-07-25 | 2014-07-28 | 8 | 1d | 0d |  |
| 10 | Excavation in Treches Connecting Beams |  | 1d | 2014-07-29 | 2014-07-29 | 9 | 1d | 0d |  |
| 11 | Underground Sanitation |  | 5d | 2014-07-30 | 2014-08-05 | 10 | 1d | 0d |  |
| 12 | FOUNDATION | manual | 18d | 2014-06-03 | 2014-06-26 |  |  |  |  |
| 13 | Pilling Balls |  | 8d | 2014-08-06 | 2014-08-15 | 11 | 1d | 0d |  |
| 14 | Foundation Beams |  | 9d | 2014-08-18 | 2014-08-28 | 13 | 1d | 0d |  |
| 15 | STRUCTURE | manual | 36d | 2014-06-03 | 2014-07-22 |  |  |  |  |
| 16 | Breast Wall |  | 5d | 2014-08-29 | 2014-09-04 | 14 | 1d | 0d |  |
| 17 | Frame |  | 26d | 2014-09-05 | 2014-10-10 | 16 | 1d | 0d |  |
| 18 | Slab |  | 5d | 2014-10-13 | 2014-10-17 | 17 | 1d | 0d |  |
| 19 | FACADES | manual | 43d | 2014-06-03 | 2014-07-31 |  |  |  |  |
| 20 | Curtain Wall |  | 20d | 2014-11-18 | 2014-12-15 | 23 | 48d | 0d |  |
| 21 | Sandwich Panel |  | 23d | 2014-12-16 | 2015-01-15 | 20 | 48d | 0d |  |
| 22 | ROOF | manual | 21d | 2014-06-03 | 2014-07-01 |  |  |  |  |
| 23 | Roof Deck |  | 21d | 2014-10-20 | 2014-11-17 | 18 | 1d | 0d |  |
| 24 | PARTITIONS | manual | 1d? | 2014-06-03 | 2014-06-03 |  |  |  |  |
| 25 | Internal Partitions | manual | 39d | 2014-06-03 | 2014-07-25 |  |  |  |  |
| 26 | 1º Floor |  | 13d | 2014-11-18 | 2014-12-04 | 23 | 1d | 0d |  |
| 27 | 2º Floor |  | 26d | 2014-12-05 | 2015-01-09 | 26 | 1d | 0d |  |
| 28 | COATINGS | manual | 1d? | 2014-06-03 | 2014-06-03 |  |  |  |  |
| 29 | Tiling | manual | 37d | 2014-06-03 | 2014-07-23 |  |  |  |  |
| 30 | 1º Floor |  | 4d | 2014-12-05 | 2014-12-10 | 26 | 1d | 0d |  |
| 31 | 2º Floor |  | 7d | 2015-01-12 | 2015-01-20 | 27 | 1d | 0d |  |
| 32 | Paint | manual | 2d | 2014-06-03 | 2014-06-04 |  |  |  |  |
| 33 | 2º Floor |  | 2d | 2015-02-06 | 2015-02-09 | 42 | 33d |  |  |
| 34 | Pavement | manual | 44d | 2014-06-03 | 2014-08-01 |  |  |  |  |
| 35 | 1º Floor Tiles |  | 24d | 2014-12-11 | 2015-01-13 | 30 | 1d | 0d |  |
| 36 | 1º Floor Concrete |  | 6d | 2015-01-23 | 2015-01-30 | 41 | 20d | 0d |  |
| 37 | 2º floor Tiles |  | 8d | 2015-01-21 | 2015-01-30 | 31 | 1d | 0d |  |
| 38 | 2º Floor Concrete |  | 3d | 2015-02-06 | 2015-02-10 | 42 | 32d |  |  |
| 39 | Carpet |  | 2d | 2015-03-06 | 2015-03-09 | 51 | 1d | 0d |  |
| 40 | Ceiling | manual | 17d | 2014-06-03 | 2014-06-25 |  |  |  |  |
| 41 | 1º Floor |  | 7d | 2015-01-14 | 2015-01-22 | 35 | 1d | 0d |  |
| 42 | 2º Floor |  | 4d | 2015-02-02 | 2015-02-05 | 37 | 1d | 0d |  |
| 43 | CARPENTRY | manual | 40d | 2014-06-03 | 2014-07-28 |  |  |  |  |
| 44 | Wood |  | 10d | 2015-03-10 | 2015-03-23 | 39 | 1d | 0d |  |
| 45 | Steel |  | 2d | 2015-01-16 | 2015-01-19 | 21 | 48d |  |  |
| 46 | EQUIPMENT | manual | 1d | 2014-06-03 | 2014-06-03 |  |  |  |  |
| 47 | Equipment and Furniture |  | 1d | 2015-03-24 | 2015-03-24 | 44 | 1d |  |  |
| 48 | FACILITIES | manual | 75d | 2014-06-03 | 2014-09-15 |  |  |  |  |
| 49 | Electric Installation |  | 20d | 2014-12-05 | 2015-01-01 | 26 | 60d |  |  |
| 50 | Plumbing and Sanitation Hanged |  | 20d | 2014-12-05 | 2015-01-01 | 26 | 60d |  |  |
| 51 | Heating and Ventilation Installation |  | 30d | 2015-01-23 | 2015-03-05 | 41 | 1d | 0d | start no earlier than 2015-01-23 |
| 52 | Safety in Case of fire Network |  | 30d | 2015-02-06 | 2015-03-19 | 42 | 1d | 0d |  |
| 53 | Installation Finishes |  | 15d | 2015-02-02 | 2015-02-20 | 36 | 20d | 0d |  |
| 54 | FINAL WORK | manual | 8d | 2014-06-03 | 2014-06-12 |  |  |  |  |
| 55 | Testing and Commissionng of Facilities |  | 4d | 2015-02-23 | 2015-02-26 | 53 | 20d |  |  |
| 56 | Actions and Final Cleaning of Worksite |  | 4d | 2015-03-20 | 2015-03-25 | 52 | 1d |  | start no earlier than 2015-03-20 |
| 57 | WASTE MANAGEMENT | manual | 211d | 2014-06-03 | 2015-03-24 |  |  |  |  |
| 58 | Waste Management |  | 212d | 2014-06-03 | 2015-03-25 |  | 0d |  |  |
| 59 | QUALITY CONTROL | manual | 211d | 2014-06-03 | 2015-03-24 |  |  |  |  |
| 60 | Quality Control |  | 212d | 2014-06-03 | 2015-03-25 |  | 0d |  |  |
| 61 | HEALTH AND SAFETY | manual | 211d | 2014-06-03 | 2015-03-24 |  |  |  |  |
| 62 | Health and Safety |  | 212d | 2014-06-03 | 2015-03-25 |  | 0d |  |  |
| 63 | END OF WORKS |  | 1d | 2015-03-26 | 2015-03-26 | 58, 60, 62, 47 | 0d |  | start no earlier than 2015-03-26 |
